# Kitchen Replacement Project

Schedule from MS Project, 2013-10-07 to 2014-02-14, costs in $.

## Calendars

- Standard: Mon-Fri 08:00-12:00, 13:00-17:00; Sat-Sun off.

## Resources

| Resource | Rate |
| --- | --- |
| Electrician | 25 |
| Cupboard Installer | 25 |
| Plumber | 12.5 |
| Tile Installer | 12.5 |
| Carpenter | 12.5 |
| Project Manager |  |

## Schedule

| ID | WBS | Task | Type | Duration | Start | Finish | Predecessors | Total slack | Constraint | Resources | Work | Cost |
| --- | --- | --- | --- | --- | --- | --- | --- | --- | --- | --- | --- | --- |
| 1 | 1 | Design/Procure |  | 1d | 2013-10-07 | 2013-10-07 |  | 94d |  |  |  | 8,150 |
| 2 | 2 | Tear Out/Prep |  | 1d | 2013-10-07 | 2013-10-07 |  | 94d |  |  |  | 2,450 |
| 3 | 3 | Material Delivery Complete | milestone | 0d | 2013-11-28 | 2013-11-28 |  | 0d | finish no earlier than 2013-11-28 |  |  |  |
| 4 | 4 | Paint Prep Complete | milestone | 0d | 2013-11-18 | 2013-11-18 |  | 54d | finish no earlier than 2013-11-18 |  |  |  |
| 5 | 5 | **Install** |  | 9d | 2014-02-03 | 2014-02-13 |  | 0d |  |  | 128h | 2,500 |
| 6 | 5.1 | Finish Electrical Outlets |  | 1d | 2014-02-03 | 2014-02-03 | 3FS+46d, 4 | 0d |  | Electrician | 8h | 250 |
| 7 | 5.2 | Install Upper Cabinets |  | 2d | 2014-02-06 | 2014-02-07 | 6 | 0d |  | Cupboard Installer | 16h | 400 |
| 8 | 5.3 | Install Lower Cabinets |  | 1d | 2014-02-04 | 2014-02-04 | 6 | 0d |  | Cupboard Installer | 8h | 200 |
| 9 | 5.4 | Install Conutertop |  | 1d | 2014-02-05 | 2014-02-05 | 8 | 0d |  | Cupboard Installer | 8h | 200 |
| 10 | 5.5 | Install Sink w/disposal |  | 1d | 2014-02-07 | 2014-02-07 | 9 | 0d |  | Plumber | 8h | 100 |
| 11 | 5.6 | Install Dishwasher |  | 2d | 2014-02-06 | 2014-02-07 | 9 | 0d |  | Plumber | 16h | 200 |
| 12 | 5.7 | Install Ceiling Light w/fan |  | 1d | 2014-02-12 | 2014-02-12 | 7 | 0d |  | Electrician | 8h | 200 |
| 13 | 5.8 | Install Microwave |  | 2d | 2014-02-10 | 2014-02-11 | 7 | 1d |  | Electrician | 16h | 400 |
| 14 | 5.9 | Install new Floor Tile |  | 1d | 2014-02-10 | 2014-02-10 | 10, 11 | 0d |  | Tile Installer | 8h | 100 |
| 15 | 5.10 | Install Stove |  | 1d | 2014-02-12 | 2014-02-12 | 14 | 0d |  | Electrician | 8h | 200 |
| 16 | 5.11 | Finish Trim |  | 2d | 2014-02-11 | 2014-02-12 | 14 | 0d |  | Carpenter | 16h | 250 |
| 17 | 5.12 | Paint Trim & Touch Up |  | 1d | 2014-02-13 | 2014-02-13 | 12, 13, 15, 16 | 0d |  | Project Manager | 8h |  |
| 18 | 5.13 | Paint Trim & Touch Up complete | milestone | 0d | 2014-02-13 | 2014-02-13 | 17 | 0d |  |  |  |  |
| 19 | 6 | Close |  | 1d | 2014-02-14 | 2014-02-14 | 18 | 0d |  | Project Manager | 8h |  |
