# KRP Budget Tear Out Prep

Schedule from MS Project, 2013-10-07 to 2014-01-31, costs in $.

## Calendars

- Standard: Mon-Fri 08:00-12:00, 13:00-17:00; Sat-Sun off.

## Resources

| Resource | Rate |
| --- | --- |
| Electrician | 25 |
| Plumber | 12.5 |
| Carpenter | 12.5 |
| Project Manager |  |

## Schedule

| ID | WBS | Task | Type | Duration | Start | Finish | Predecessors | Total slack | Constraint | Resources | Work | Cost |
| --- | --- | --- | --- | --- | --- | --- | --- | --- | --- | --- | --- | --- |
| 1 | 1 | Design/Procure |  | 1d | 2013-10-07 | 2013-10-07 |  | 84d |  |  |  | 8,150 |
| 2 | 2 | Permits Complete | milestone | 0d | 2013-11-18 | 2013-11-18 |  | 44d | finish no earlier than 2013-11-18 |  |  |  |
| 3 | 3 | Material Delivery Complete | milestone | 0d | 2013-11-28 | 2013-11-28 |  | 0d | finish no earlier than 2013-11-28 |  |  |  |
| 4 | 4 | **Tear Out/Prep** |  | 10d | 2014-01-20 | 2014-01-31 |  | 0d |  |  | 128h | 2,450 |
| 5 | 4.1 | Disc & remove Burners |  | 2d | 2014-01-20 | 2014-01-21 | 2, 3FS+36d | 0d |  | Electrician | 16h | 400 |
| 6 | 4.2 | Disc & Remove sink /faucets |  | 1d | 2014-01-20 | 2014-01-20 | 2, 3FS+36d | 1d |  | Plumber | 8h | 100 |
| 7 | 4.3 | Disc & remove oven |  | 1d | 2014-01-22 | 2014-01-22 | 2, 3FS+36d | 0d |  | Electrician | 8h | 200 |
| 8 | 4.4 | Remove countertop |  | 1d | 2014-01-22 | 2014-01-22 | 5, 6 | 0d |  | Carpenter | 8h | 100 |
| 9 | 4.5 | Remove lwr Cabinets |  | 2d | 2014-01-23 | 2014-01-24 | 8 | 0d |  | Carpenter | 16h | 200 |
| 10 | 4.6 | Remove Upper Cabinets |  | 1d | 2014-01-23 | 2014-01-23 | 7 | 0d |  | Carpenter | 8h | 100 |
| 11 | 4.7 | Remove soffit |  | 1d | 2014-01-24 | 2014-01-24 | 10 | 0d |  | Carpenter | 8h | 100 |
| 12 | 4.8 | Remove drywall behind cupboards |  | 1d | 2014-01-27 | 2014-01-27 | 9, 11 | 0d |  | Carpenter | 8h | 100 |
| 13 | 4.9 | Remove floor tile |  | 1d | 2014-01-28 | 2014-01-28 | 9, 11 | 1d |  | Carpenter | 8h | 100 |
| 14 | 4.10 | Rough In Elec |  | 2d | 2014-01-28 | 2014-01-29 | 12 | 0d |  | Electrician | 16h | 600 |
| 15 | 4.11 | Rough In Plumbing |  | 1d | 2014-01-28 | 2014-01-28 | 12 | 1d |  | Plumber | 8h | 200 |
| 16 | 4.12 | Install new Drywall |  | 1d | 2014-01-30 | 2014-01-30 | 13, 14, 15 | 0d |  | Carpenter | 8h | 150 |
| 17 | 4.13 | Paint |  | 1d | 2014-01-31 | 2014-01-31 | 16 | 0d |  | Project Manager | 8h | 100 |
| 18 | 4.14 | Paint Prep Complete | milestone | 0d | 2014-01-31 | 2014-01-31 | 17 | 0d |  |  |  |  |
| 19 | 5 | Install |  | 1d? | 2013-10-07 | 2013-10-07 |  | 84d |  |  |  | 2,500 |
| 20 | 6 | Close |  | 1d? | 2013-10-07 | 2013-10-07 |  | 84d |  |  |  |  |
