# KRP Duration Composite2

Schedule from MS Project, 2013-10-07 to 2013-12-05.

## Calendars

- Standard: Mon-Fri 08:00-12:00, 13:00-17:00; Sat-Sun off.

## Schedule

| ID | WBS | Task | Duration | Start | Finish | Predecessors | Total slack | Free slack |
| --- | --- | --- | --- | --- | --- | --- | --- | --- |
| 1 | 1 | **Design/Procure** | 34d | 2013-10-07 | 2013-11-21 |  | 0d |  |
| 2 | 1.1 | Design Concept | 5d | 2013-10-07 | 2013-10-11 |  | 0d |  |
| 3 | 1.2 | Order Appliances | 5d | 2013-10-14 | 2013-10-18 | 2 | 0d |  |
| 4 | 1.3 | Design Layout | 1d | 2013-10-14 | 2013-10-14 | 2 | 0d |  |
| 5 | 1.4 | Order Tile, Sink, Disposal | 2d | 2013-10-15 | 2013-10-16 | 4 | 2d | 0d |
| 6 | 1.5 | Order Cupboards & Countertop | 1d | 2013-10-15 | 2013-10-15 | 4 | 3d | 0d |
| 7 | 1.6 | Design Electrical | 2d | 2013-10-15 | 2013-10-16 | 4 | 0d |  |
| 8 | 1.7 | Order Electrical Fixtures | 2d | 2013-10-17 | 2013-10-18 | 7 | 0d |  |
| 9 | 1.8 | Contract Cupboard Install | 3d | 2013-10-16 | 2013-10-18 | 6 | 6d | 3d |
| 10 | 1.9 | Contract Tile Install | 3d | 2013-10-17 | 2013-10-21 | 5 | 5d | 2d |
| 11 | 1.10 | Contract Carp, Elec, & Plumber | 5d | 2013-10-17 | 2013-10-23 | 4, 5, 7 | 3d | 0d |
| 12 | 1.11 | Secure Permits | 8d | 2013-10-24 | 2013-11-04 | 9, 10, 11 | 3d | 0d |
| 13 | 1.12 | Deliver Materials Ordered | 24d | 2013-10-21 | 2013-11-21 | 3, 5, 6, 8 | 0d |  |
| 14 | 2 | **Tear Out/Prep** | 10d | 2013-11-05 | 2013-11-18 |  | 3d |  |
| 15 | 2.1 | Disc & remove Burners | 2d | 2013-11-05 | 2013-11-06 | 12 | 3d | 0d |
| 16 | 2.2 | Disc & Remove sink /faucets | 1d | 2013-11-05 | 2013-11-05 | 12 | 4d | 1d |
| 17 | 2.3 | Disc & remove oven | 1d | 2013-11-05 | 2013-11-05 | 12 | 5d | 0d |
| 18 | 2.4 | Remove countertop | 1d | 2013-11-07 | 2013-11-07 | 15, 16 | 3d | 0d |
| 19 | 2.5 | Remove lwr Cabinets | 2d | 2013-11-08 | 2013-11-11 | 18 | 3d | 0d |
| 20 | 2.6 | Remove Upper Cabinets | 1d | 2013-11-06 | 2013-11-06 | 17 | 5d | 0d |
| 21 | 2.7 | Remove soffit | 1d | 2013-11-07 | 2013-11-07 | 20 | 5d | 2d |
| 22 | 2.8 | Remove drywall behind cupboards | 1d | 2013-11-12 | 2013-11-12 | 19, 21 | 3d | 0d |
| 23 | 2.9 | Remove floor tile | 1d | 2013-11-12 | 2013-11-12 | 19, 21 | 5d | 2d |
| 24 | 2.10 | Rough In Elec | 2d | 2013-11-13 | 2013-11-14 | 22 | 3d | 0d |
| 25 | 2.11 | Rough In Plumbing | 1d | 2013-11-13 | 2013-11-13 | 22 | 4d | 1d |
| 26 | 2.12 | Install new Drywall | 1d | 2013-11-15 | 2013-11-15 | 23, 24, 25 | 3d | 0d |
| 27 | 2.13 | Paint Prep | 1d | 2013-11-18 | 2013-11-18 | 26 | 3d |  |

| ID | WBS | Task | Duration | Start | Finish | Predecessors | Total slack | Free slack |
| --- | --- | --- | --- | --- | --- | --- | --- | --- |
| 28 | 3 | **Install** | 9d | 2013-11-22 | 2013-12-04 |  | 0d |  |
| 29 | 3.1 | Finish Electrical Outlets | 1d | 2013-11-22 | 2013-11-22 | 13, 27 | 0d |  |
| 30 | 3.2 | Install Upper Cabinets | 2d | 2013-11-25 | 2013-11-26 | 29 | 3d | 0d |
| 31 | 3.3 | Install Lower Cabinets | 1d | 2013-11-25 | 2013-11-25 | 29 | 0d |  |
| 32 | 3.4 | Install Countertop | 1d | 2013-11-26 | 2013-11-26 | 31 | 0d |  |
| 33 | 3.5 | Install Sink w/disposal | 1d | 2013-11-27 | 2013-11-27 | 32 | 1d |  |
| 34 | 3.6 | Install Dishwasher | 2d | 2013-11-27 | 2013-11-28 | 32 | 0d |  |
| 35 | 3.7 | Install Ceiling Light w/fan | 1d | 2013-11-27 | 2013-11-27 | 30 | 4d |  |
| 36 | 3.8 | Install Microwave | 2d | 2013-11-27 | 2013-11-28 | 30 | 3d |  |
| 37 | 3.9 | Install new Floor Tile | 1d | 2013-11-29 | 2013-11-29 | 33, 34 | 0d |  |
| 38 | 3.10 | Install Stove | 1d | 2013-12-02 | 2013-12-02 | 37 | 1d |  |
| 39 | 3.11 | Finish Trim | 2d | 2013-12-02 | 2013-12-03 | 37 | 0d |  |
| 40 | 3.12 | Paint Trim & Touch Up | 1d | 2013-12-04 | 2013-12-04 | 35, 36, 38, 39 | 0d |  |
| 41 | 4 | Close | 1d? | 2013-12-05 | 2013-12-05 | 40 | 0d |  |
