# Kitchen Replacement Project

Schedule from MS Project, 2013-10-07 to 2013-11-28.

## Calendars

- Standard: Mon-Fri 08:00-12:00, 13:00-17:00; Sat-Sun off.

## Resources

| Resource |
| --- |
| Project Manager |
| Spouse |
| Designer |
| Lowes |

## Schedule

| ID | WBS | Task | Type | Duration | Start | Finish | Predecessors | Total slack | Free slack | Resources | Work |
| --- | --- | --- | --- | --- | --- | --- | --- | --- | --- | --- | --- |
| 1 | 1 | **Design/Procure** |  | 39d | 2013-10-07 | 2013-11-28 |  | 0d |  |  | 488h |
| 2 | 1.1 | Design Concept |  | 5d | 2013-10-07 | 2013-10-11 |  | 0d |  | Project Manager | 40h |
| 3 | 1.2 | Order Appliances |  | 5d | 2013-10-14 | 2013-10-18 | 2 | 5d |  | Spouse | 40h |
| 4 | 1.3 | Design Layout |  | 1d | 2013-10-14 | 2013-10-14 | 2 | 0d |  | Designer | 8h |
| 5 | 1.4 | Order Tile, Sink, Disposal |  | 2d | 2013-10-21 | 2013-10-22 | 4 | 3d | 0d | Spouse | 16h |
| 6 | 1.5 | Order Cupboards & Ctrtop |  | 1d | 2013-10-23 | 2013-10-23 | 4 | 2d | 0d | Spouse | 8h |
| 7 | 1.6 | Design Electrical |  | 2d | 2013-10-15 | 2013-10-16 | 4 | 0d |  | Designer | 16h |
| 8 | 1.7 | Order Elect. Fixtures |  | 2d | 2013-10-24 | 2013-10-25 | 7 | 0d |  | Spouse | 16h |
| 9 | 1.8 | Contract Cupboard Install |  | 3d | 2013-10-24 | 2013-10-28 | 6 | 15d | 7d | Project Manager | 24h |
| 10 | 1.9 | Contract Tile Install |  | 3d | 2013-10-30 | 2013-11-01 | 5 | 11d | 3d | Project Manager | 24h |
| 11 | 1.10 | Contract Carp, Elec, Plumb |  | 5d | 2013-10-23 | 2013-11-06 | 4, 5, 7 | 8d | 0d | Project Manager | 40h |
| 12 | 1.11 | Secure Permits |  | 8d | 2013-11-07 | 2013-11-18 | 9, 10, 11 | 8d | 0d | Project Manager | 64h |
| 13 | 1.12 | Delv. Matls. Ordered |  | 24d | 2013-10-28 | 2013-11-28 | 3, 5, 6, 8 | 0d |  | Lowes | 192h |
| 14 | 1.13 | Permits Complete | milestone | 0d | 2013-11-18 | 2013-11-18 | 12 | 8d |  |  |  |
| 15 | 1.14 | Material Delivery Complete | milestone | 0d | 2013-11-28 | 2013-11-28 | 13 | 0d |  |  |  |
| 16 | 2 | Tear Out and Prep |  | 1d? | 2013-10-07 | 2013-10-07 |  | 38d |  |  |  |
| 17 | 3 | Install |  | 1d? | 2013-10-07 | 2013-10-07 |  | 38d |  |  |  |
| 18 | 4 | Close |  | 1d? | 2013-10-07 | 2013-10-07 |  | 38d |  |  |  |
