# Kitchen Replacement Project

Schedule from MS Project, 2013-10-07 to 2013-12-06.

## Calendars

- Standard: Mon-Fri 08:00-12:00, 13:00-17:00; Sat-Sun off.

## Resources

| Resource |
| --- |
| Electrician |
| Cupboard Installer |
| Plumber |
| Tile Installer |
| Carpenter |
| Project Manager |

## Schedule

| ID | WBS | Task | Type | Duration | Start | Finish | Predecessors | Total slack | Free slack | Constraint | Resources | Work |
| --- | --- | --- | --- | --- | --- | --- | --- | --- | --- | --- | --- | --- |
| 1 | 1 | Design/Procure |  | 1d | 2013-10-07 | 2013-10-07 |  | 44d |  |  |  |  |
| 2 | 2 | Tear Out/Prep |  | 1d | 2013-10-07 | 2013-10-07 |  | 44d |  |  |  |  |
| 3 | 3 | Material Delivery Complete | milestone | 0d | 2013-11-21 | 2013-11-21 |  | 0d |  | finish no earlier than 2013-11-21 |  |  |
| 4 | 4 | Paint Prep Complete | milestone | 0d | 2013-11-18 | 2013-11-18 |  | 3d |  | finish no earlier than 2013-11-18 |  |  |
| 5 | 5 | **Install** |  | 10d? | 2013-11-22 | 2013-12-05 |  | 0d |  |  |  | 128h |
| 6 | 5.1 | Finish Electrical Outlets |  | 1d | 2013-11-22 | 2013-11-22 | 3, 4 | 0d |  |  | Electrician | 8h |
| 7 | 5.2 | Install Upper Cabinets |  | 2d | 2013-11-27 | 2013-11-28 | 6 | 1d | 0d |  | Cupboard Installer | 16h |
| 8 | 5.3 | Install Lower Cabinets |  | 1d | 2013-11-25 | 2013-11-25 | 6 | 0d |  |  | Cupboard Installer | 8h |
| 9 | 5.4 | Install Conutertop |  | 1d? | 2013-11-26 | 2013-11-26 | 8 | 0d |  |  | Cupboard Installer | 8h |
| 10 | 5.5 | Install Sink w/disposal |  | 1d | 2013-11-29 | 2013-11-29 | 9 | 0d |  |  | Plumber | 8h |
| 11 | 5.6 | Install Dishwasher |  | 2d | 2013-11-27 | 2013-11-28 | 9 | 1d |  |  | Plumber | 16h |
| 12 | 5.7 | Install Ceiling Light w/fan |  | 1d | 2013-12-03 | 2013-12-03 | 7 | 1d |  |  | Electrician | 8h |
| 13 | 5.8 | Install Microwave |  | 2d | 2013-11-29 | 2013-12-02 | 7 | 2d |  |  | Electrician | 16h |
| 14 | 5.9 | Install new Floor Tile |  | 1d | 2013-12-02 | 2013-12-02 | 10, 11 | 0d |  |  | Tile Installer | 8h |
| 15 | 5.10 | Install Stove |  | 1d | 2013-12-04 | 2013-12-04 | 14 | 0d |  |  | Electrician | 8h |
| 16 | 5.11 | Finish Trim |  | 2d | 2013-12-03 | 2013-12-04 | 14 | 0d |  |  | Carpenter | 16h |
| 17 | 5.12 | Paint Trim & Touch Up |  | 1d | 2013-12-05 | 2013-12-05 | 12, 13, 15, 16 | 0d |  |  | Project Manager | 8h |
| 18 | 5.13 | Paint Trim & Touch Up complete | milestone | 0d | 2013-12-05 | 2013-12-05 | 17 | 0d |  |  |  |  |
| 19 | 6 | Close |  | 1d | 2013-12-06 | 2013-12-06 | 18 | 0d |  |  | Project Manager | 8h |
