# Kitchen Replacement Project

Schedule from MS Project, 2013-10-07 to 2013-11-21.

## Calendars

- Standard: Mon-Fri 08:00-12:00, 13:00-17:00; Sat-Sun off.

## Schedule

| ID | WBS | Task | Type | Duration | Start | Finish | Predecessors | Total slack | Free slack |
| --- | --- | --- | --- | --- | --- | --- | --- | --- | --- |
| 1 | 1 | **Design/Procure** |  | 34d | 2013-10-07 | 2013-11-21 |  | 0d |  |
| 2 | 1.1 | Design Concept |  | 5d | 2013-10-07 | 2013-10-11 |  | 0d |  |
| 3 | 1.2 | Order Appliances |  | 5d | 2013-10-14 | 2013-10-18 | 2 | 0d |  |
| 4 | 1.3 | Design Layout |  | 1d | 2013-10-14 | 2013-10-14 | 2 | 0d |  |
| 5 | 1.4 | Order Tile, Sink, Disposal |  | 2d | 2013-10-15 | 2013-10-16 | 4 | 2d | 0d |
| 6 | 1.5 | Order Cupboards & Ctrtop |  | 1d | 2013-10-15 | 2013-10-15 | 4 | 3d | 0d |
| 7 | 1.6 | Design Electrical |  | 2d | 2013-10-15 | 2013-10-16 | 4 | 0d |  |
| 8 | 1.7 | Order Elect. Fixtures |  | 2d | 2013-10-17 | 2013-10-18 | 7 | 0d |  |
| 9 | 1.8 | Contract Cupboard Install |  | 3d | 2013-10-16 | 2013-10-18 | 6 | 16d | 3d |
| 10 | 1.9 | Contract Tile Install |  | 3d | 2013-10-17 | 2013-10-21 | 5 | 15d | 2d |
| 11 | 1.10 | Contract Carp, Elec, Plumb |  | 5d | 2013-10-17 | 2013-10-23 | 4, 5, 7 | 13d | 0d |
| 12 | 1.11 | Secure Permits |  | 8d | 2013-10-24 | 2013-11-04 | 9, 10, 11 | 13d | 0d |
| 13 | 1.12 | Delv. Matls. Ordered |  | 24d | 2013-10-21 | 2013-11-21 | 3, 5, 6, 8 | 0d |  |
| 14 | 1.13 | Permits Complete | milestone | 0d | 2013-11-04 | 2013-11-04 | 12 | 13d |  |
| 15 | 1.14 | Material Delivery Complete | milestone | 0d | 2013-11-21 | 2013-11-21 | 13 | 0d |  |
| 16 | 2 | Tear Out and Prep |  | 1d? | 2013-10-07 | 2013-10-07 |  | 33d |  |
| 17 | 3 | Install |  | 1d? | 2013-10-07 | 2013-10-07 |  | 33d |  |
| 18 | 4 | Close |  | 1d? | 2013-10-07 | 2013-10-07 |  | 33d |  |
