# Kitchen Replacement Project

Schedule from MS Project, 2013-10-07 to 2013-12-05.

## Calendars

- Standard: Mon-Fri 08:00-12:00, 13:00-17:00; Sat-Sun off.

## Schedule

| ID | WBS | Task | Type | Duration | Start | Finish | Predecessors | Total slack | Free slack | Constraint |
| --- | --- | --- | --- | --- | --- | --- | --- | --- | --- | --- |
| 1 | 1 | Design/Procure |  | 1d | 2013-10-07 | 2013-10-07 |  | 43d |  |  |
| 2 | 2 | Tear Out/Prep |  | 1d | 2013-10-07 | 2013-10-07 |  | 43d |  |  |
| 3 | 3 | Material Delivery Complete | milestone | 0d | 2013-11-21 | 2013-11-21 |  | 0d |  | finish no earlier than 2013-11-21 |
| 4 | 4 | Paint Prep Complete | milestone | 0d | 2013-11-18 | 2013-11-18 |  | 3d |  | finish no earlier than 2013-11-18 |
| 5 | 5 | **Install** |  | 9d | 2013-11-22 | 2013-12-04 |  | 0d |  |  |
| 6 | 5.1 | Finish Electrical Outlets |  | 1d | 2013-11-22 | 2013-11-22 | 3, 4 | 0d |  |  |
| 7 | 5.2 | Install Upper Cabinets |  | 2d | 2013-11-25 | 2013-11-26 | 6 | 3d | 0d |  |
| 8 | 5.3 | Install Lower Cabinets |  | 1d | 2013-11-25 | 2013-11-25 | 6 | 0d |  |  |
| 9 | 5.4 | Install Conutertop |  | 1d | 2013-11-26 | 2013-11-26 | 8 | 0d |  |  |
| 10 | 5.5 | Install Sink w/disposal |  | 1d | 2013-11-27 | 2013-11-27 | 9 | 1d |  |  |
| 11 | 5.6 | Install Dishwasher |  | 2d | 2013-11-27 | 2013-11-28 | 9 | 0d |  |  |
| 12 | 5.7 | Install Ceiling Light w/fan |  | 1d | 2013-11-27 | 2013-11-27 | 7 | 4d |  |  |
| 13 | 5.8 | Install Microwave |  | 2d | 2013-11-27 | 2013-11-28 | 7 | 3d |  |  |
| 14 | 5.9 | Install new Floor Tile |  | 1d | 2013-11-29 | 2013-11-29 | 10, 11 | 0d |  |  |
| 15 | 5.10 | Install Stove |  | 1d | 2013-12-02 | 2013-12-02 | 14 | 1d |  |  |
| 16 | 5.11 | Finish Trim |  | 2d | 2013-12-02 | 2013-12-03 | 14 | 0d |  |  |
| 17 | 5.12 | Paint Trim & Touch Up |  | 1d | 2013-12-04 | 2013-12-04 | 12, 13, 15, 16 | 0d |  |  |
| 18 | 5.13 | Paint Trim & Touch Up complete | milestone | 0d | 2013-12-04 | 2013-12-04 | 17 | 0d |  |  |
| 19 | 6 | Close |  | 1d | 2013-12-05 | 2013-12-05 | 18 | 0d |  |  |
