# Kitchen Replacement Project

Schedule from MS Project, 2013-10-07 to 2013-11-18.

## Calendars

- Standard: Mon-Fri 08:00-12:00, 13:00-17:00; Sat-Sun off.

## Resources

| Resource |
| --- |
| Electrician |
| Plumber |
| Carpenter |
| Project Manager |

## Schedule

| ID | WBS | Task | Type | Duration | Start | Finish | Predecessors | Total slack | Constraint | Resources | Work |
| --- | --- | --- | --- | --- | --- | --- | --- | --- | --- | --- | --- |
| 1 | 1 | **Design/Procure** |  | 0d | 2013-11-04 | 2013-11-04 |  | 0d |  |  |  |
| 2 | 1.1 | Permits Complete | milestone | 0d | 2013-11-04 | 2013-11-04 |  | 0d | finish no earlier than 2013-11-04 |  |  |
| 3 | 2 | **Tear Out/Prep** |  | 10d | 2013-11-05 | 2013-11-18 |  | 0d |  |  | 128h |
| 4 | 2.1 | Disc & remove Burners |  | 2d | 2013-11-05 | 2013-11-06 | 2 | 0d |  | Electrician | 16h |
| 5 | 2.2 | Disc & Remove sink /faucets |  | 1d | 2013-11-05 | 2013-11-05 | 2 | 1d |  | Plumber | 8h |
| 6 | 2.3 | Disc & remove oven |  | 1d | 2013-11-07 | 2013-11-07 | 2 | 0d |  | Electrician | 8h |
| 7 | 2.4 | Remove countertop |  | 1d | 2013-11-07 | 2013-11-07 | 4, 5 | 0d |  | Carpenter | 8h |
| 8 | 2.5 | Remove lwr Cabinets |  | 2d | 2013-11-08 | 2013-11-11 | 7 | 0d |  | Carpenter | 16h |
| 9 | 2.6 | Remove Upper Cabinets |  | 1d | 2013-11-08 | 2013-11-08 | 6 | 0d |  | Carpenter | 8h |
| 10 | 2.7 | Remove soffit |  | 1d | 2013-11-11 | 2013-11-11 | 9 | 0d |  | Carpenter | 8h |
| 11 | 2.8 | Remove drywall behind cupboards |  | 1d | 2013-11-12 | 2013-11-12 | 8, 10 | 0d |  | Carpenter | 8h |
| 12 | 2.9 | Remove floor tile |  | 1d | 2013-11-13 | 2013-11-13 | 8, 10 | 1d |  | Carpenter | 8h |
| 13 | 2.10 | Rough In Elec |  | 2d | 2013-11-13 | 2013-11-14 | 11 | 0d |  | Electrician | 16h |
| 14 | 2.11 | Rough In Plumbing |  | 1d | 2013-11-13 | 2013-11-13 | 11 | 1d |  | Plumber | 8h |
| 15 | 2.12 | Install new Drywall |  | 1d | 2013-11-15 | 2013-11-15 | 12, 13, 14 | 0d |  | Carpenter | 8h |
| 16 | 2.13 | Paint |  | 1d | 2013-11-18 | 2013-11-18 | 15 | 0d |  | Project Manager | 8h |
| 17 | 2.14 | Paint Prep Complete | milestone | 0d | 2013-11-18 | 2013-11-18 | 16 | 0d |  |  |  |
| 18 | 3 | Install |  | 1d? | 2013-10-07 | 2013-10-07 |  | 30d |  |  |  |
| 19 | 4 | Close |  | 1d? | 2013-10-07 | 2013-10-07 |  | 30d |  |  |  |
